# CRONOGRAMA PROYECTO SNR MUNICIPIOS AJUSTE CARTAGO

Schedule from MS Project, 2025-03-17 to 2025-12-15, A marks actual dates.

## Calendars

- Estándar: Mon-Fri 09:00-13:00, 15:00-19:00; Sat-Sun off. Exceptions (off unless hours are given): 2025-04-17 to 2025-04-18 (festivo), 2025-05-01 (festivo), 2025-06-02 (festivo), 2025-06-23 (festivo), 2025-06-30 (festivo), 2025-08-07 (festivo), 2025-08-18 (festivo), 2025-10-13 (festivo), 2025-11-03 (festivo), 2025-11-17 (festivo), 2025-12-08 (festivo).

## Resources

| Resource |
| --- |
| SNR |
| SKAPHE |
| 82 libros |

## Schedule

| ID | WBS | Task | Type | Duration | Start | Finish | Predecessors | Complete | Remaining | Total slack | Free slack | Constraint | Resources | Work | Actual work | %Planeado | %Retraso | Text30 |
| --- | --- | --- | --- | --- | --- | --- | --- | --- | --- | --- | --- | --- | --- | --- | --- | --- | --- | --- |
| 1 | 1 | **CRONOGRAMA SNR MUNICIPIOS** |  | 184d | 2025-03-17 A | 2025-12-15 |  | 19% | 149.83d | 0d |  |  |  | 82035.2h | 14200.3h | 55% | 36% |  |
| 2 | 1.1 | **Yopal** |  | 182d | 2025-03-18 A | 2025-12-12 |  | 21% | 143.85d | 1d |  |  |  | 9496h | 1912.91h | 55% | 34% | G3 |
| 3 | 1.1.1 | Visita tecnica de reconocimiento | milestone | 0d | 2025-03-18 A | 2025-03-18 A |  | 100% |  |  |  | start no earlier than 2025-03-18 | SKAPHE |  |  | 100% | 0% |  |
| 4 | 1.1.2 | Entrega informe Visita Tecnica | milestone | 0d | 2025-04-02 A | 2025-04-02 A |  | 100% |  |  |  | start no earlier than 2025-03-31 | SKAPHE |  |  | 100% | 0% |  |
| 5 | 1.1.3 | **Saneamiento Ambiental Preventivo** |  | 12d | 2025-04-09 A | 2025-04-29 A |  | 100% |  |  |  |  | SKAPHE | 48h | 48h | 100% | 0% |  |
| 6 | 1.1.3.1 | Actividades de saneamiento |  | 2d | 2025-04-09 A | 2025-04-10 A |  | 100% |  |  |  | start no earlier than 2025-04-09 | SKAPHE | 16h | 16h | 100% | 0% |  |
| 7 | 1.1.3.2 | Entregar de Informe Saneamiento Ambiental Preventivo | milestone | 0d | 2025-04-29 A | 2025-04-29 A |  | 100% |  |  |  | start no earlier than 2025-04-29 | SKAPHE |  |  | 100% | 0% |  |
| 8 | 1.1.4 | Alistamiento, Entrega y Embalaje |  | 4d | 2025-04-09 A | 2025-04-14 A |  | 100% |  |  |  | finish no earlier than 2025-04-14 | SKAPHE | 32h | 32h | 100% | 0% |  |
| 9 | 1.1.5 | Cargue, Traslado y descargue |  | 1d | 2025-04-15 A | 2025-04-15 A | 8 | 100% |  |  |  |  | SKAPHE | 8h | 8h | 100% | 0% |  |
| 10 | 1.1.6 | Entrega de acta de cargue y descargue | milestone | 0d | 2025-04-15 A | 2025-04-15 A | 9 | 100% |  |  |  |  |  |  |  | 100% | 0% |  |
| 11 | 1.1.7 | **Proceso de Intervención en Conservación Documental-Primeros Auxilios** |  | 89d | 2025-04-24 A | 2025-09-03 |  | 48% | 46.26d | 69d |  |  | SKAPHE | 2760h | 1219.91h | 84% | 36% |  |
| 12 | 1.1.7.1 | Actividades de primeros auxilios |  | 44d | 2025-04-24 A | 2025-06-27 | 9 | 74% | 11.44d | 114d | 11d |  | SKAPHE | 352h | 260.48h | 100% | 26% |  |
| 13 | 1.1.7.2 | **Realizar Entrega de libros** |  | 72d | 2025-05-20 A | 2025-09-03 |  | 40% | 43.3d | 69d |  |  | SKAPHE | 1696h | 617.52h | 81% | 41% |  |
| 14 | 1.1.7.2.1 | Entregas Primeros Auxilios |  | 70d | 2025-05-20 A | 2025-09-01 | 12SS+6d | 63% | 25.6d | 71d | 0d | start no earlier than 2025-05-20 | SKAPHE | 560h | 355.2h | 83% | 20% |  |
| 15 | 1.1.7.2.2 | Aprobación entregas Primeros Auxilios |  | 70d | 2025-05-22 A | 2025-09-03 | 14SS+2d | 16% | 58.6d | 69d | 0d |  | SNR | 560h | 91.2h | 80% | 64% |  |
| 16 | 1.1.8 | **Procesos de Digitalizacion** |  | 70d | 2025-06-06 A | 2025-09-17 |  | 26% | 51.8d | 59d |  |  | SKAPHE | 2000h | 443.2h | 66% | 40% |  |
| 17 | 1.1.8.1 | Realizar actividades de digitalización |  | 60d | 2025-06-06 A | 2025-09-03 | 15SS+10d | 42% | 34.8d | 69d | 0d |  | SKAPHE | 480h | 201.6h | 77% | 35% |  |
| 18 | 1.1.8.2 | **Realizar entrega de libros** |  | 60d | 2025-06-20 A | 2025-09-17 |  | 10% | 54d | 59d |  |  | SKAPHE | 960h | 96h | 60% | 50% |  |
| 19 | 1.1.8.2.1 | Entregar libros digitalizados |  | 60d | 2025-06-20 A | 2025-09-17 | 17SS+10d | 10% | 54d | 59d |  |  | SKAPHE | 480h | 48h | 60% | 50% |  |
| 20 | 1.1.9 | **Proceso de Descripcion e Indexacion** |  | 61d | 2025-06-20 A | 2025-09-18 |  | 9% | 55.28d | 58d |  |  | SKAPHE | 1840h | 161.79h | 59% | 50% |  |
| 21 | 1.1.9.1 | Realizar actividades de descripción e indexación |  | 50d | 2025-06-20 A | 2025-09-03 | 17SS+3d | 12% | 44d | 69d | 15d |  | SKAPHE | 400h | 48h | 72% | 60% |  |
| 22 | 1.1.9.2 | **Realizar entrega de libros** |  | 41d | 2025-07-22 A | 2025-09-18 |  | 8% | 37.85d | 58d |  |  | SKAPHE | 952h | 78.06h | 39% | 31% |  |
| 23 | 1.1.9.2.1 | Entregar libros indexados |  | 39d | 2025-07-22 A | 2025-09-16 | 21SS+5d | 15% | 33d | 60d | 0d |  | SKAPHE | 312h | 48h | 41% | 26% |  |
| 24 | 1.1.9.2.2 | Aprobar libros digitalizados e indexados |  | 39d | 2025-07-24 | 2025-09-18 | 23SS+2d |  |  | 28d | 0d |  | SNR | 312h |  | 36% | 36% |  |

Notes:
- 4: Entrega Informe
- 7: Entrega Informe
- 9: 43 libros
- 14: 5 libros
- 19: 5 libros
- 23: 5 libros

| ID | WBS | Task | Type | Duration | Start | Finish | Predecessors | Complete | Remaining | Total slack | Free slack | Constraint | Resources | Work | Actual work | %Planeado | %Retraso | Text30 |
| --- | --- | --- | --- | --- | --- | --- | --- | --- | --- | --- | --- | --- | --- | --- | --- | --- | --- | --- |
| 25 | 1.1.10 | **Proceso de Realmacenamiento en Unidades de Conservacion** |  | 60d | 2025-08-05 | 2025-10-30 |  |  |  | 29d |  |  | SKAPHE | 504h |  | 10% | 10% |  |
| 26 | 1.1.10.1 | Realizar actividades de realmacenamiento |  | 60d | 2025-08-05 | 2025-10-30 | 24SS+5d |  |  | 29d |  | start no earlier than 2025-08-05 |  |  |  | 10% | 10% |  |
| 27 | 1.1.10.2 | **Realizar entrega de libros** |  | 4d | 2025-10-16 | 2025-10-21 |  |  |  | 1d |  |  |  | 24h |  | 0% | 0% |  |
| 28 | 1.1.10.2.1 | Entrega semanales realmacenamiento |  | 1d | 2025-10-16 | 2025-10-16 | 26SS+5d |  |  | 1d | 0d | start no earlier than 2025-10-16 | SKAPHE | 8h |  | 0% | 0% |  |
| 29 | 1.1.10.2.2 | Aprobación semanales realmacenamiento |  | 2d | 2025-10-20 | 2025-10-21 | 28SS+2d |  |  | 1d | 0d |  | SNR | 16h |  | 0% | 0% |  |
| 30 | 1.1.11 | **Proceso de discos duros** |  | 67d | 2025-07-28 | 2025-10-31 |  |  |  | 28d |  |  | SKAPHE | 2008h |  | 18% | 18% |  |
| 31 | 1.1.11.1 | Realizar copiado de DD |  | 2d | 2025-07-28 | 2025-07-29 | 24SS+2d |  |  | 28d | 0d | start no earlier than 2025-05-02 | SKAPHE | 16h |  | 100% | 100% |  |
| 32 | 1.1.11.2 | **Entrega de Discos duros** |  | 62d | 2025-08-04 | 2025-10-31 |  |  |  | 28d |  |  | SKAPHE | 1456h |  | 11% | 11% |  |
| 33 | 1.1.11.2.1 | Entrega DD |  | 60d | 2025-08-04 | 2025-10-29 | 31SS+5d |  |  | 28d | 0d |  | SKAPHE | 480h |  | 12% | 12% |  |
| 34 | 1.1.11.2.2 | Realizar aprobación entrega DD |  | 60d | 2025-08-06 | 2025-10-31 | 33SS+2d |  |  | 28d |  |  | SNR | 480h |  | 8% | 8% |  |
| 35 | 1.1.12 | Traslado de Libros del Antiguo Sistema Registral al Archivo Central |  | 37d | 2025-10-20 | 2025-12-12 | 29SS |  |  | 1d |  | start no earlier than 2025-09-26 | SKAPHE | 296h |  | 0% | 0% |  |
| 36 | 1.2 | **Cartago** |  | 182d | 2025-03-18 A | 2025-12-12 |  | 16% | 152.91d | 1d |  |  |  | 14424h | 2476.62h | 55% | 39% | G1 |
| 37 | 1.2.1 | Visita tecnica de reconocimiento | milestone | 0d | 2025-03-18 A | 2025-03-18 A |  | 100% |  |  |  | start no earlier than 2025-03-18 | SKAPHE |  |  | 100% | 0% |  |
| 38 | 1.2.2 | Entrega informe Visita Tecnica | milestone | 0d | 2025-04-02 A | 2025-04-02 A | 37 | 100% |  |  |  |  | SKAPHE |  |  | 100% | 0% |  |
| 39 | 1.2.3 | **Saneamiento Ambiental Preventivo** |  | 14d | 2025-04-21 A | 2025-05-12 A |  | 100% |  |  |  |  | SKAPHE | 16h | 16h | 100% | 0% |  |
| 40 | 1.2.3.1 | Actividades de saneamiento |  | 1d | 2025-04-21 A | 2025-04-21 A |  | 100% |  |  |  |  |  |  |  | 100% | 0% |  |
| 41 | 1.2.3.2 | Entrega de Informe Saneamiento Ambiental Preventivo | milestone | 0d | 2025-05-12 A | 2025-05-12 A | 40 | 100% |  |  |  |  | SKAPHE |  |  | 100% | 0% |  |
| 42 | 1.2.4 | **Alistamiento, Entrega y Embalaje** |  | 19d | 2025-04-24 A | 2025-05-21 A |  | 100% |  |  |  |  | SKAPHE | 304h | 304h | 100% | 0% |  |
| 43 | 1.2.4.1 | Alistamiento No 1 |  | 14d | 2025-04-24 A | 2025-05-14 A |  | 100% |  |  |  | finish no earlier than 2025-05-14 | SKAPHE | 112h | 112h | 100% | 0% |  |
| 44 | 1.2.4.2 | Alistamiento No 2 |  | 5d | 2025-05-15 A | 2025-05-21 A | 43 | 100% |  |  |  | finish no earlier than 2025-05-21 | SKAPHE | 40h | 40h | 100% | 0% |  |
| 45 | 1.2.5 | **Cargue, Traslado y descargue** |  | 7d | 2025-05-15 A | 2025-05-23 A |  | 100% |  |  |  |  | SKAPHE | 88h | 88h | 100% | 0% |  |
| 46 | 1.2.5.1 | Traslado 1 |  | 2d | 2025-05-15 A | 2025-05-16 A | 43 | 100% |  |  |  | start no earlier than 2025-05-15 | SKAPHE | 16h | 16h | 100% | 0% |  |
| 47 | 1.2.5.2 | Traslado 2 |  | 2d | 2025-05-22 A | 2025-05-23 A | 44 | 100% |  |  |  | finish no earlier than 2025-05-23 | SKAPHE | 16h | 16h | 100% | 0% |  |
| 48 | 1.2.6 | Entrega de acta de cargue y descargue | milestone | 0d | 2025-05-23 A | 2025-05-23 A | 47 | 100% |  |  |  |  |  |  |  | 100% | 0% |  |

Notes:
- 28: 5 libros
- 32: 43 libros
- 41: Entrega Informe
- 43: 300 libros
- 44: 423 libros
- 46: 300
- 47: 423

| ID | WBS | Task | Duration | Start | Finish | Predecessors | Complete | Remaining | Total slack | Free slack | Constraint | Resources | Work | Actual work | %Planeado | %Retraso |
| --- | --- | --- | --- | --- | --- | --- | --- | --- | --- | --- | --- | --- | --- | --- | --- | --- |
| 49 | 1.2.7 | **Proceso de Intervención en Conservación Documental-Primeros Auxilios** | 88d | 2025-05-19 A | 2025-09-24 |  | 39% | 53.31d | 54d |  |  | SKAPHE | 3368h | 1291.41h | 67% | 28% |
| 50 | 1.2.7.1 | Actividades de primeros auxilios | 85d | 2025-05-19 A | 2025-09-19 | 46 | 38% | 52.6d | 57d | 19d |  | SKAPHE | 680h | 259.2h | 69% | 31% |
| 51 | 1.2.7.2 | **Entrega de Libros** | 63d | 2025-06-25 A | 2025-09-24 |  | 40% | 37.59d | 54d |  |  | SKAPHE; SNR | 1984h | 800.1h | 54% | 14% |
| 52 | 1.2.7.2.1 | Entregas Primeros Auxilios | 61d | 2025-06-25 A | 2025-09-22 | 50SS+6d | 53% | 28.6d | 56d | 0d |  | SKAPHE | 488h | 259.2h | 56% | 3% |
| 53 | 1.2.7.2.2 | Aprobación entregas Primeros Auxilios | 61d | 2025-06-27 A | 2025-09-24 | 52SS+2d | 28% | 44.2d | 54d | 0d |  | SNR | 488h | 134.4h | 52% | 24% |
| 54 | 1.2.8 | **Procesos de Digitalizacion** | 65d | 2025-06-30 A | 2025-10-01 |  | 25% | 48.8d | 49d |  |  | SKAPHE | 1416h | 365.68h | 48% | 23% |
| 55 | 1.2.8.1 | Realizar actividades de digitalización | 65d | 2025-06-30 A | 2025-10-01 | 53SS+2d | 27% | 47.4d | 49d | 0d |  |  |  |  | 48% | 21% |
| 56 | 1.2.8.2 | **Realizar entrega de libros** | 63d | 2025-07-02 A | 2025-09-30 |  | 23% | 48.7d | 50d |  |  | SKAPHE | 896h | 228.8h | 48% | 25% |
| 57 | 1.2.8.2.1 | Entregar libros digitalizados | 63d | 2025-07-02 A | 2025-09-30 | 55SS+11d | 23% | 48.7d | 50d |  |  | SKAPHE | 504h | 114.4h | 48% | 25% |
| 58 | 1.2.9 | **Proceso de Descripcion e Indexacion** | 78d | 2025-07-05 A | 2025-10-27 |  | 16% | 65.68d | 32d |  |  | SKAPHE | 2688h | 411.53h | 35% | 19% |
| 59 | 1.2.9.1 | Realizar actividades de descripción e indexación | 63d | 2025-07-05 A | 2025-10-03 | 55SS+3d | 23% | 48.44d | 47d | 6d |  | SKAPHE | 504h | 116.48h | 43% | 20% |
| 60 | 1.2.9.2 | **Entrega de libros** | 67d | 2025-07-22 A | 2025-10-27 |  | 12% | 58.83d | 32d |  |  | SKAPHE | 1560h | 208h | 24% | 12% |
| 61 | 1.2.9.2.1 | Entregar libros indexados | 63d | 2025-07-22 A | 2025-10-21 | 59SS+5d | 25% | 47.4d | 36d | 0d |  | SKAPHE | 504h | 124.8h | 25% | 0% |
| 62 | 1.2.9.2.2 | Aprobar libros digitalizados e indexados | 65d | 2025-07-24 | 2025-10-27 | 61SS+2d |  |  | 5d | 0d |  | SNR | 520h |  | 22% | 22% |
| 63 | 1.2.10 | **Proceso de Realmacenamiento en Unidades de Conservacion** | 80d | 2025-08-05 | 2025-12-01 |  |  |  | 9d |  |  | SKAPHE | 2752h |  | 8% | 8% |
| 64 | 1.2.10.1 | Realizar actividades de realmacenamiento | 70d | 2025-08-05 | 2025-11-14 | 62SS+5d |  |  | 17d | 8d | start no earlier than 2025-08-05 | SKAPHE | 560h |  | 9% | 9% |
| 65 | 1.2.10.2 | **Entrega de libros** | 67d | 2025-08-26 | 2025-12-01 |  |  |  | 9d |  |  | SKAPHE | 1552h |  | 0% | 0% |
| 66 | 1.2.10.2.1 | Entrega semanales realmacenamiento | 62d | 2025-08-26 | 2025-11-24 | 64SS+5d |  |  | 9d | 0d | start no earlier than 2025-08-26 | SKAPHE | 496h |  | 0% | 0% |
| 67 | 1.2.10.2.2 | Aprobación semanales realmacenamiento | 65d | 2025-08-28 | 2025-12-01 | 66SS+2d |  |  | 9d |  |  | SNR | 520h |  | 0% | 0% |
| 68 | 1.2.11 | **Proceso discos duros** | 90d | 2025-07-28 | 2025-12-05 |  |  |  | 5d |  |  | SKAPHE | 3376h |  | 13% | 13% |
| 69 | 1.2.11.1 | Realizar copiado de DD | 90d | 2025-07-28 | 2025-12-05 | 62SS+2d |  |  | 5d | 0d |  | SKAPHE | 720h |  | 13% | 13% |
| 70 | 1.2.11.2 | **Entrega de libros en DD** | 82d | 2025-08-04 | 2025-12-02 |  |  |  | 8d |  |  | SKAPHE | 1936h |  | 9% | 9% |
| 71 | 1.2.11.2.1 | Entrega DD | 80d | 2025-08-04 | 2025-11-28 | 69SS+5d |  |  | 8d | 0d |  | SKAPHE | 640h |  | 9% | 9% |
| 72 | 1.2.11.2.2 | Realizar aprobación entrega DD | 80d | 2025-08-06 | 2025-12-02 | 71SS+2d |  |  | 8d |  |  | SNR | 640h |  | 6% | 6% |
| 73 | 1.2.12 | Traslado de Libros del Antiguo Sistema Registral al Archivo Central | 52d | 2025-09-26 | 2025-12-12 | 67SS+5d |  |  | 1d |  | start no earlier than 2025-09-26 | SKAPHE | 416h |  | 0% | 0% |

Notes:
- 52: 118 libros
- 57: 118 libros
- 61: 118 libros
- 66: 118 libros
- 71: 118 libros

| ID | WBS | Task | Type | Duration | Start | Finish | Predecessors | Complete | Remaining | Total slack | Free slack | Constraint | Resources | Work | Actual work | %Planeado | %Retraso | Text30 |
| --- | --- | --- | --- | --- | --- | --- | --- | --- | --- | --- | --- | --- | --- | --- | --- | --- | --- | --- |
| 74 | 1.3 | **Riohacha** |  | 183d | 2025-03-17 A | 2025-12-12 |  | 14% | 157.44d | 1d |  |  |  | 7843.2h | 1029.92h | 55% | 41% | G2 |
| 75 | 1.3.1 | Visita tecnica de reconocimiento |  | 1d | 2025-03-17 A | 2025-03-17 A |  | 100% |  |  |  | start no earlier than 2025-03-17 | SKAPHE | 8h | 8h | 100% | 0% |  |
| 76 | 1.3.2 | Entrega informe Visita Tecnica | milestone | 0d | 2025-04-02 A | 2025-04-02 A | 75 | 100% |  |  |  | start no earlier than 2025-03-31 | SKAPHE |  |  | 100% | 0% |  |
| 77 | 1.3.3 | **Saneamiento Ambiental Preventivo** |  | 13d | 2025-04-22 A | 2025-05-12 A |  | 100% |  |  |  |  | SKAPHE | 24h | 24h | 100% | 0% |  |
| 78 | 1.3.3.1 | Actividades de saneamiento |  | 1d | 2025-04-22 A | 2025-04-22 A |  | 100% |  |  |  | start no earlier than 2025-04-22 | SKAPHE | 8h | 8h | 100% | 0% |  |
| 79 | 1.3.3.2 | Entrega de Informe Saneamiento Ambiental Preventivo | milestone | 0d | 2025-05-12 A | 2025-05-12 A |  | 100% |  |  |  | start no earlier than 2025-05-12 | SKAPHE |  |  | 100% | 0% |  |
| 80 | 1.3.4 | Alistamiento, Entrega y Embalaje |  | 7d | 2025-04-24 A | 2025-05-05 A |  | 100% |  |  |  | start no earlier than 2025-04-24 | SKAPHE | 56h | 56h | 100% | 0% |  |
| 81 | 1.3.5 | Cargue, Traslado y descargue |  | 1d | 2025-05-08 A | 2025-05-08 A | 80 | 100% |  |  |  | start no earlier than 2025-05-08 | SKAPHE | 8h | 8h | 100% | 0% |  |
| 82 | 1.3.6 | Entrega de acta de cargue y descargue | milestone | 0d | 2025-05-08 A | 2025-05-08 A | 81 | 100% |  |  |  |  |  |  |  | 100% | 0% |  |
| 83 | 1.3.7 | **Procesos de Conservacion a nivel de Primeros Auxilios** |  | 74d | 2025-05-09 A | 2025-08-27 |  | 24% | 56.31d | 74d |  |  | SKAPHE | 2008h | 450.96h | 88% | 64% |  |
| 84 | 1.3.7.1 | Actividades de primeros auxilios |  | 40d | 2025-05-09 A | 2025-07-08 | 81 | 28% | 28.8d | 108d | 12d |  | SKAPHE | 320h | 89.6h | 100% | 72% |  |
| 85 | 1.3.7.2 | **Realizar entregas de libros** |  | 47d | 2025-06-18 A | 2025-08-27 |  | 22% | 36.62d | 74d |  |  | SKAPHE | 1096h | 242.09h | 81% | 59% |  |
| 86 | 1.3.7.2.1 | Entregas Primeros Auxilios |  | 45d | 2025-06-18 A | 2025-08-25 | 84SS+15d | 26% | 33.52d | 76d | 0d |  | SKAPHE | 360h | 91.84h | 84% | 58% |  |
| 87 | 1.3.7.2.2 | Aprobación entregas Primeros Auxilios |  | 45d | 2025-06-20 A | 2025-08-27 | 86SS+2d | 19% | 36.6d | 74d | 0d |  | SNR | 360h | 67.2h | 80% | 61% |  |
| 88 | 1.3.8 | **Proceso de Digitalizacion** |  | 49.2d | 2025-06-23 A | 2025-09-04 |  | 19% | 39.64d | 68.8d |  |  | SKAPHE | 1515.2h | 285.61h | 71% | 52% |  |
| 89 | 1.3.8.1 | Realizar actividades de digitalización |  | 46d | 2025-06-23 A | 2025-08-29 | 87SS+2d | 24% | 34.93d | 72d | 0d |  | SKAPHE | 368h | 88.56h | 76% | 52% |  |
| 90 | 1.3.8.2 | **Realizar Entrega de libros** |  | 48.2d | 2025-06-25 A | 2025-09-04 |  | 15% | 41.07d | 68.8d |  |  | SKAPHE | 753.6h | 108.8h | 71% | 56% |  |
| 91 | 1.3.8.2.1 | Entregar libros digitalizados |  | 46d | 2025-06-25 A | 2025-09-04 | 89SS+10d | 15% | 39.2d | 68.8d |  |  | SKAPHE | 368h | 54.4h | 74% | 59% |  |
| 92 | 1.3.9 | **Proceso de Descripcion e Indexacion** |  | 56d | 2025-06-25 A | 2025-09-15 |  | 19% | 45.32d | 61d |  |  | SKAPHE | 1192h | 197.35h | 61% | 42% |  |
| 93 | 1.3.9.1 | Realizar actividades de descripción e indexación |  | 42d | 2025-06-25 A | 2025-08-26 | 89SS+3d | 17% | 34.86d | 75d | 32d |  | SKAPHE | 336h | 57.12h | 81% | 64% |  |
| 94 | 1.3.9.2 | **Realizar entrega de libros** |  | 19d | 2025-08-20 A | 2025-09-15 |  | 22% | 14.86d | 61d |  |  | SKAPHE | 408h | 99.02h | 0% | -22% |  |
| 95 | 1.3.9.2.1 | Entregar libros indexados |  | 15d | 2025-08-20 A | 2025-09-09 | 93SS+5d | 46% | 8.03d | 65d | 0d |  | SKAPHE | 120h | 55.76h | 0% | -46% |  |
| 96 | 1.3.9.2.2 | Aprobar libros digitalizados e indexados |  | 17d | 2025-08-22 | 2025-09-15 | 95SS+2d |  |  | 29d | 0d |  | SNR | 136h |  | 0% | 0% |  |
| 97 | 1.3.10 | **Proceso de Realmacenamiento en Unidades de Conservacion** |  | 63d | 2025-08-29 | 2025-11-28 |  |  |  | 7d |  |  | SKAPHE | 1504h |  | 0% | 0% |  |
| 98 | 1.3.10.1 | Realizar actividades de realmacenamiento |  | 41d | 2025-08-29 | 2025-10-27 | 96SS+5d |  |  | 29d | 28d | start no earlier than 2025-08-05 | SKAPHE | 328h |  | 0% | 0% |  |

Notes:
- 76: Entrega Informe
- 79: Entrega Informe
- 81: 43 libros
- 86: 100 libros
- 91: 100 libros
- 95: 100 libros

| ID | WBS | Task | Type | Duration | Start | Finish | Predecessors | Complete | Remaining | Total slack | Free slack | Constraint | Resources | Work | Actual work | %Planeado | %Retraso | Text30 |
| --- | --- | --- | --- | --- | --- | --- | --- | --- | --- | --- | --- | --- | --- | --- | --- | --- | --- | --- |
| 99 | 1.3.10.2 | **Realizar entrega de libros** |  | 30d | 2025-10-16 | 2025-11-28 |  |  |  | 1d |  |  | SKAPHE | 672h |  | 0% | 0% |  |
| 100 | 1.3.10.2.1 | Entrega semanales realmacenamiento |  | 26d | 2025-10-16 | 2025-11-24 | 98SS+5d |  |  | 1d | 0d | start no earlier than 2025-10-16 | SKAPHE | 208h |  | 0% | 0% |  |
| 101 | 1.3.10.2.2 | Aprobación semanales realmacenamiento |  | 28d | 2025-10-20 | 2025-11-28 | 100SS+2d |  |  | 1d | 0d |  | SNR | 224h |  | 0% | 0% |  |
| 102 | 1.3.11 | **Proceso Discos Duros** |  | 37d | 2025-09-22 | 2025-11-13 |  |  |  | 20d |  |  | SKAPHE | 1272h |  | 0% | 0% |  |
| 103 | 1.3.11.1 | Realizar copiado de DD |  | 30d | 2025-09-22 | 2025-11-04 | 96SS+2d |  |  | 20d | 0d | start no earlier than 2025-09-22 | SKAPHE | 240h |  | 0% | 0% |  |
| 104 | 1.3.11.2 | **Realizar entrega de DD** |  | 32d | 2025-09-29 | 2025-11-13 |  |  |  | 20d |  |  | SKAPHE | 736h |  | 0% | 0% |  |
| 105 | 1.3.11.2.1 | Entrega DD |  | 30d | 2025-09-29 | 2025-11-11 | 103SS+5d |  |  | 20d | 0d |  | SKAPHE | 240h |  | 0% | 0% |  |
| 106 | 1.3.11.2.2 | Realizar aprobación entrega DD |  | 30d | 2025-10-01 | 2025-11-13 | 105SS+2d |  |  | 20d |  |  | SNR | 240h |  | 0% | 0% |  |
| 107 | 1.3.12 | Traslado de Libros del Antiguo Sistema Registral al Archivo Central |  | 32d | 2025-10-27 | 2025-12-12 | 101SS+5d |  |  | 1d |  | start no earlier than 2025-09-26 | SKAPHE | 256h |  | 0% | 0% |  |
| 108 | 1.4 | **Sabana Larga** |  | 182d | 2025-03-18 A | 2025-12-12 |  | 9% | 165.16d | 1d |  |  |  | 13240h | 1194.82h | 55% | 46% | G2 |
| 109 | 1.4.1 | Visita tecnica de reconocimiento |  | 1d | 2025-03-18 A | 2025-03-18 A |  | 100% |  |  |  | start no earlier than 2025-03-18 | SKAPHE | 8h | 8h | 100% | 0% |  |
| 110 | 1.4.2 | Entrega informe Visita Tecnica | milestone | 0d | 2025-04-02 A | 2025-04-02 A | 109 | 100% |  |  |  | start no earlier than 2025-03-31 | SKAPHE |  |  | 100% | 0% |  |
| 111 | 1.4.3 | **Saneamiento Ambiental Preventivo** |  | 15d | 2025-05-06 A | 2025-05-26 A |  | 100% |  |  |  |  | SKAPHE | 248h | 248h | 100% | 0% |  |
| 112 | 1.4.3.1 | Actividades de saneamiento |  | 1d | 2025-05-08 A | 2025-05-08 A |  | 100% |  |  |  | start no earlier than 2025-05-07 | SKAPHE | 8h | 8h | 100% | 0% |  |
| 113 | 1.4.3.2 | Entrega de Informe Saneamiento Ambiental Preventivo |  | 15d | 2025-05-06 A | 2025-05-26 A |  | 100% |  |  |  | start no earlier than 2025-05-06 | SKAPHE | 120h | 120h | 100% | 0% |  |
| 114 | 1.4.4 | Alistamiento, Entrega y Embalaje |  | 9d | 2025-05-09 A | 2025-05-21 A | 112 | 100% |  |  |  | finish no earlier than 2025-05-21 | SKAPHE | 72h | 72h | 100% | 0% |  |
| 115 | 1.4.5 | Cargue, Traslado y descargue |  | 2d | 2025-05-22 A | 2025-05-23 A | 114 | 100% |  |  |  | start no earlier than 2025-05-22 | SKAPHE | 16h | 16h | 100% | 0% |  |
| 116 | 1.4.6 | Entrega de acta de cargue y descargue | milestone | 0d | 2025-06-03 A | 2025-06-03 A | 115 | 100% |  |  |  | start no earlier than 2025-06-03 | SKAPHE |  |  | 100% | 0% |  |
| 117 | 1.4.7 | **Proceso de Intervención en Conservación Documental-Primeros Auxilios** |  | 93d | 2025-05-26 A | 2025-10-08 |  | 13% | 80.93d | 44d |  |  | SKAPHE | 3384h | 443.93h | 58% | 45% |  |
| 118 | 1.4.7.1 | Actividades de primeros auxilios |  | 82d | 2025-05-26 A | 2025-09-23 | 115 | 13% | 71.5d | 55d | 3d | start no earlier than 2025-05-05 | SKAPHE | 656h | 84h | 66% | 53% |  |
| 119 | 1.4.7.2 | **Realizar entrega de libros** |  | 84d | 2025-06-09 A | 2025-10-08 |  | 13% | 73.03d | 44d |  |  | SKAPHE | 1984h | 259.13h | 54% | 41% |  |
| 120 | 1.4.7.2.1 | Entregas Primeros Auxilios |  | 82d | 2025-06-09 A | 2025-10-06 | 118SS+6d | 13% | 71.5d | 46d | 0d |  | SKAPHE | 656h | 84h | 55% | 42% |  |
| 121 | 1.4.7.2.2 | Aprobación entregas Primeros Auxilios |  | 82d | 2025-06-11 A | 2025-10-08 | 120SS+2d | 13% | 71.08d | 44d | 5d |  | SNR | 656h | 87.36h | 52% | 39% |  |
| 122 | 1.4.8 | **Proceso de Digitalizacion** |  | 56d | 2025-06-20 A | 2025-09-11 |  | 15% | 47.6d | 63d |  |  | SKAPHE | 1616h | 235.36h | 64% | 49% |  |
| 123 | 1.4.8.1 | Realizar actividades de digitalización |  | 51d | 2025-06-20 A | 2025-09-04 | 121SS+2d | 17% | 42.33d | 68d | 0d |  | SKAPHE | 408h | 69.36h | 71% | 54% |  |

Notes:
- 100: 100 libros
- 105: 100 libros
- 110: Entrega Informe
- 113: Entrega Informe
- 115: 348 libros
- 116: Entrega Informe
- 120: 170 libros

| ID | WBS | Task | Type | Duration | Start | Finish | Predecessors | Complete | Remaining | Total slack | Free slack | Constraint | Resources | Work | Actual work | %Planeado | %Retraso | Text30 |
| --- | --- | --- | --- | --- | --- | --- | --- | --- | --- | --- | --- | --- | --- | --- | --- | --- | --- | --- |
| 124 | 1.4.8.2 | **Realizar entrega de libros** |  | 51d | 2025-06-30 A | 2025-09-11 |  | 13% | 44.37d | 63d |  |  | SKAPHE | 760h | 98.8h | 61% | 48% |  |
| 125 | 1.4.8.2.1 | Entregar libros digitalizados |  | 51d | 2025-06-30 A | 2025-09-11 | 123SS+10d | 13% | 44.37d | 63d |  |  | SKAPHE | 408h | 53.04h | 61% | 48% |  |
| 126 | 1.4.9 | **Proceso de Descripcion e Indexacion** |  | 97d | 2025-06-26 A | 2025-11-14 |  | 6% | 90.96d | 19d |  |  | SKAPHE | 2968h | 171.53h | 34% | 28% |  |
| 127 | 1.4.9.1 | Realizar actividades de descripción e indexación |  | 55d | 2025-06-26 A | 2025-09-15 | 123SS+3d | 12% | 48.37d | 61d | 12d |  | SKAPHE | 440h | 53.04h | 60% | 48% |  |
| 128 | 1.4.9.2 | **Realizar entrega de libros** |  | 80d | 2025-07-22 A | 2025-11-14 |  | 4% | 76.67d | 19d |  |  | SKAPHE | 1888h | 78.67h | 20% | 16% |  |
| 129 | 1.4.9.2.1 | Entregar libros indexados |  | 78d | 2025-07-22 A | 2025-11-12 | 127SS+5d | 8% | 71.5d | 21d | 0d |  | SKAPHE | 624h | 52h | 21% | 13% |  |
| 130 | 1.4.9.2.2 | Aprobar libros digitalizados e indexados |  | 78d | 2025-07-24 | 2025-11-14 | 129SS+2d |  |  | 19d | 0d | finish no earlier than 2025-06-05 | SNR | 624h |  | 18% | 18% |  |
| 131 | 1.4.10 | **Proceso de Realmacenamiento en Unidades de Conservacion** |  | 75d | 2025-08-05 | 2025-11-24 |  |  |  | 14d |  |  | SKAPHE | 2416h |  | 8% | 8% |  |
| 132 | 1.4.10.1 | Realizar actividades de realmacenamiento |  | 51d | 2025-08-05 | 2025-10-17 | 130SS+5d |  |  | 22d | 8d | start no earlier than 2025-08-05 | SKAPHE | 408h |  | 12% | 12% |  |
| 133 | 1.4.10.2 | **Realizar entrega de libros** |  | 62d | 2025-08-26 | 2025-11-24 |  |  |  | 14d |  |  | SKAPHE | 1408h |  | 0% | 0% |  |
| 134 | 1.4.10.2.1 | Entrega semanales realmacenamiento |  | 62d | 2025-08-26 | 2025-11-24 | 132SS+5d |  |  | 14d | 0d | start no earlier than 2025-08-26 | SKAPHE | 496h |  | 0% | 0% |  |
| 135 | 1.4.10.2.2 | Aprobación semanales realmacenamiento |  | 52d | 2025-08-28 | 2025-11-11 | 134SS+2d |  |  | 22d | 16d | finish no earlier than 2025-06-05 | SNR | 416h |  | 0% | 0% |  |
| 136 | 1.4.11 | **Proceso de discos Duros** |  | 58d | 2025-07-28 | 2025-10-20 |  |  |  | 37d |  |  | SKAPHE | 2096h |  | 21% | 21% |  |
| 137 | 1.4.11.1 | Realizar copiado de DD |  | 50d | 2025-07-28 | 2025-10-07 | 130SS+2d |  |  | 37d | 0d |  | SKAPHE | 400h |  | 24% | 24% |  |
| 138 | 1.4.11.2 | **Entrega de DD** |  | 53d | 2025-08-04 | 2025-10-20 |  |  |  | 37d |  |  | SKAPHE | 1232h |  | 13% | 13% |  |
| 139 | 1.4.11.2.1 | Entrega DD |  | 50d | 2025-08-04 | 2025-10-15 | 137SS+5d |  |  | 37d | 0d |  | SKAPHE | 400h |  | 14% | 14% |  |
| 140 | 1.4.11.2.2 | Realizar aprobación entrega DD |  | 51d | 2025-08-06 | 2025-10-20 | 139SS+2d |  |  | 37d |  |  | SNR | 408h |  | 10% | 10% |  |
| 141 | 1.4.12 | Traslado de Libros del Antiguo Sistema Registral al Archivo Central |  | 52d | 2025-09-26 | 2025-12-12 | 135SS+5d |  |  | 1d |  | start no earlier than 2025-09-26 | SKAPHE | 416h |  | 0% | 0% |  |
| 142 | 1.5 | **Carmen de Bolivar** |  | 180d | 2025-03-20 A | 2025-12-12 |  | 7% | 168.18d | 1d |  |  |  | 7696h | 464.81h | 54% | 47% | G2 |
| 143 | 1.5.1 | Visita tecnica de reconocimiento |  | 1d | 2025-03-20 A | 2025-03-20 A |  | 100% |  |  |  | start no earlier than 2025-03-20 | SKAPHE | 8h | 8h | 100% | 0% |  |
| 144 | 1.5.2 | Entrega informe Visita Tecnica | milestone | 0d | 2025-04-02 A | 2025-04-02 A |  | 100% |  |  |  | start no earlier than 2025-03-31 | SKAPHE |  |  | 100% | 0% |  |
| 145 | 1.5.3 | **Saneamiento Ambiental Preventivo** |  | 16d | 2025-06-09 A | 2025-07-02 A |  | 100% |  |  |  |  | SKAPHE | 256h | 256h | 100% | 0% |  |
| 146 | 1.5.3.1 | Realizar actividades de saneamiento ambiental |  | 1d | 2025-06-09 A | 2025-06-09 A |  | 100% |  |  |  | start no earlier than 2025-06-09 | SKAPHE | 8h | 8h | 100% | 0% |  |
| 147 | 1.5.3.2 | Entrega de Informe Saneamiento Ambiental Preventivo |  | 15d | 2025-06-10 A | 2025-07-02 A | 146 | 100% |  |  |  | start no earlier than 2025-06-10 | SKAPHE | 120h | 120h | 100% | 0% |  |
| 148 | 1.5.4 | Alistamiento, Entrega y Embalaje |  | 8d | 2025-06-10 A | 2025-06-19 A | 146 | 100% |  |  |  | start no earlier than 2025-06-10 | SKAPHE | 64h | 64h | 100% | 0% |  |
| 149 | 1.5.5 | Cargue, Traslado y descargue |  | 1d | 2025-06-20 A | 2025-06-20 A | 148 | 100% |  |  |  | start no earlier than 2025-05-30 | SKAPHE | 8h | 8h | 100% | 0% |  |
| 150 | 1.5.6 | Entrega de acta de cargue y descargue | milestone | 0d | 2025-06-24 A | 2025-06-24 A | 149 | 100% |  |  |  | start no earlier than 2025-06-24 | SKAPHE |  |  | 100% | 0% |  |

Notes:
- 125: 170 libros
- 129: 170 libros
- 134: 170 libros
- 139: 170 libros
- 144: Entrega Informe
- 147: Entrega Informe
- 149: 348 libros

| ID | WBS | Task | Type | Duration | Start | Finish | Predecessors | Complete | Remaining | Total slack | Free slack | Constraint | Resources | Work | Actual work | %Planeado | %Retraso |
| --- | --- | --- | --- | --- | --- | --- | --- | --- | --- | --- | --- | --- | --- | --- | --- | --- | --- |
| 151 | 1.5.7 | **Proceso de Intervención en Conservación Documental-Primeros Auxilios** |  | 64d | 2025-06-21 A | 2025-09-24 |  | 8% | 58.88d | 54d |  |  | SKAPHE | 1728h | 128.81h | 55% | 47% |
| 152 | 1.5.7.1 | Actividades de primeros auxilios |  | 60d | 2025-06-21 A | 2025-09-18 | 149 | 8% | 55.2d | 58d | 26d |  | SKAPHE | 480h | 38.4h | 58% | 50% |
| 153 | 1.5.7.2 | **Realizar entrega de libros** |  | 32d | 2025-08-11 A | 2025-09-24 |  | 8% | 29.44d | 54d |  |  | SKAPHE | 736h | 61.21h | 9% | 1% |
| 154 | 1.5.7.2.1 | Entregas Primeros Auxilios |  | 30d | 2025-08-11 A | 2025-09-22 | 152SS+6d | 16% | 25.2d | 56d | 0d |  | SKAPHE | 240h | 38.4h | 10% | -6% |
| 155 | 1.5.7.2.2 | Aprobación entregas Primeros Auxilios |  | 30d | 2025-08-13 | 2025-09-24 | 154SS+2d |  |  | 42d | 0d |  | SNR | 240h |  | 3% | 3% |
| 156 | 1.5.8 | **Proceso de Digitalizacion** |  | 40d | 2025-08-15 | 2025-10-10 |  |  |  | 42d |  |  | SKAPHE | 1136h |  | 0% | 0% |
| 157 | 1.5.8.1 | Realizar actividades de digitalización |  | 40d | 2025-08-15 | 2025-10-10 | 155SS+2d |  |  | 42d |  |  | SKAPHE | 320h |  | 0% | 0% |
| 158 | 1.5.8.2 | **Realizar entrega de libros** |  | 31d | 2025-08-28 | 2025-10-09 |  |  |  | 43d |  |  | SKAPHE | 496h |  | 0% | 0% |
| 159 | 1.5.8.2.1 | Entregar libros digitalizados |  | 31d | 2025-08-28 | 2025-10-09 | 155SS+10d |  |  | 43d |  |  | SKAPHE | 248h |  | 0% | 0% |
| 160 | 1.5.9 | **Proceso de Descripcion e Indexacion** |  | 39d | 2025-08-19 | 2025-10-10 |  |  |  | 42d |  |  | SKAPHE | 1336h |  | 0% | 0% |
| 161 | 1.5.9.1 | Realizar actividades de descripción e indexación |  | 31d | 2025-08-19 | 2025-09-30 | 155SS+3d |  |  | 45d | 3d |  | SKAPHE | 248h |  | 0% | 0% |
| 162 | 1.5.9.2 | **Realizar entrega de libros** |  | 34d | 2025-08-26 | 2025-10-10 |  |  |  | 42d |  |  | SKAPHE | 776h |  | 0% | 0% |
| 163 | 1.5.9.2.1 | Entregar libros indexados |  | 31d | 2025-08-26 | 2025-10-07 | 161SS+2d |  |  | 42d | 0d | start no earlier than 2025-08-26 | SKAPHE | 248h |  | 0% | 0% |
| 164 | 1.5.9.2.2 | Aprobar libros digitalizados e indexados |  | 32d | 2025-08-28 | 2025-10-10 | 163SS+2d |  |  | 42d | 0d | finish no earlier than 2025-06-24 | SNR | 256h |  | 0% | 0% |
| 165 | 1.5.10 | **Proceso de Realmacenamiento en Unidades de Conservacion** |  | 50d | 2025-09-04 | 2025-11-14 |  |  |  | 15d |  |  | SKAPHE | 1176h |  | 0% | 0% |
| 166 | 1.5.10.1 | Actividades de realmacenamiento |  | 40d | 2025-09-04 | 2025-10-30 | 164SS+5d |  |  | 25d | 24d | start no earlier than 2025-08-05 | SKAPHE | 320h |  | 0% | 0% |
| 167 | 1.5.10.2 | **Realizar entrega de libros** |  | 21d | 2025-10-16 | 2025-11-14 |  |  |  | 1d |  |  | SKAPHE | 456h |  | 0% | 0% |
| 168 | 1.5.10.2.1 | Entrega semanales realmacenamiento |  | 17d | 2025-10-16 | 2025-11-10 | 166SS+5d |  |  | 1d | 0d | start no earlier than 2025-10-16 | SKAPHE | 136h |  | 0% | 0% |
| 169 | 1.5.10.2.2 | Aprobación semanales realmacenamiento |  | 19d | 2025-10-20 | 2025-11-14 | 168SS+2d |  |  | 1d | 0d |  | SNR | 152h |  | 0% | 0% |
| 170 | 1.5.11 | **Proceso de discos Duros** |  | 49d | 2025-09-01 | 2025-11-10 |  |  |  | 23d |  |  | SKAPHE | 1728h |  | 0% | 0% |
| 171 | 1.5.11.1 | Realizar copiado de discos duros | milestone | 40d | 2025-09-01 | 2025-10-27 | 164SS+2d |  |  | 23d | 0d |  | SKAPHE | 320h |  | 0% | 0% |
| 172 | 1.5.11.2 | **Realizar entrega de DD** |  | 44d | 2025-09-08 | 2025-11-10 |  |  |  | 23d |  |  | SKAPHE | 1016h |  | 0% | 0% |
| 173 | 1.5.11.2.1 | Entrega DD |  | 41d | 2025-09-08 | 2025-11-05 | 171SS+5d |  |  | 23d | 0d |  | SKAPHE | 328h |  | 0% | 0% |
| 174 | 1.5.11.2.2 | Realizar aprobación entrega DD | milestone | 42d | 2025-09-10 | 2025-11-10 | 173SS+2d |  |  | 23d |  | finish no earlier than 2025-06-30 | SNR | 336h |  | 0% | 0% |
| 175 | 1.5.12 | Traslado de Libros del Antiguo Sistema Registral al Archivo Central | milestone | 32d | 2025-10-27 | 2025-12-12 | 169SS+5d |  |  | 1d |  | start no earlier than 2025-09-26 | SKAPHE | 256h |  | 0% | 0% |

Notes:
- 154: 110 libros
- 159: 110 libros
- 163: 110 libros
- 168: 110 libros
- 173: 110 libros

| ID | WBS | Task | Type | Duration | Start | Finish | Predecessors | Complete | Remaining | Total slack | Free slack | Constraint | Resources | Work | Actual work | %Planeado | %Retraso | Text30 |
| --- | --- | --- | --- | --- | --- | --- | --- | --- | --- | --- | --- | --- | --- | --- | --- | --- | --- | --- |
| 176 | 1.6 | **Cerete** |  | 180d | 2025-03-20 A | 2025-12-12 |  | 35% | 117.69d | 1d |  |  |  | 10792h | 4008.3h | 54% | 19% | G1 |
| 177 | 1.6.1 | Visita tecnica de reconocimiento |  | 1d | 2025-03-20 A | 2025-03-20 A |  | 100% |  |  |  | start no earlier than 2025-03-20 | SKAPHE | 8h | 8h | 100% | 0% |  |
| 178 | 1.6.2 | Entrega informe Visita Tecnica | milestone | 0d | 2025-04-02 A | 2025-04-02 A |  | 100% |  |  |  | start no earlier than 2025-03-31 | SKAPHE |  |  | 100% | 0% |  |
| 179 | 1.6.3 | **Saneamiento Ambiental Preventivo** |  | 16d | 2025-05-23 A | 2025-06-16 A |  | 100% |  |  |  |  | SKAPHE | 256h | 256h | 100% | 0% |  |
| 180 | 1.6.3.1 | Actividades de saneamiento |  | 1d | 2025-05-23 A | 2025-05-23 A |  | 100% |  |  |  | start no earlier than 2025-05-23 | SKAPHE | 8h | 8h | 100% | 0% |  |
| 181 | 1.6.3.2 | Entrega de Informe Saneamiento Ambiental Preventivo |  | 15d | 2025-05-26 A | 2025-06-16 A |  | 100% |  |  |  | start no earlier than 2025-05-26 | SKAPHE | 120h | 120h | 100% | 0% |  |
| 182 | 1.6.4 | Alistamiento, Entrega y Embalaje |  | 7d | 2025-05-26 A | 2025-06-04 A | 180 | 100% |  |  |  |  | SKAPHE | 56h | 56h | 100% | 0% |  |
| 183 | 1.6.5 | Cargue, Traslado y descargue |  | 1d | 2025-06-05 A | 2025-06-05 A | 182 | 100% |  |  |  |  | SKAPHE | 8h | 8h | 100% | 0% |  |
| 184 | 1.6.6 | Entrega de acta de cargue y descargue | milestone | 0d | 2025-06-18 A | 2025-06-18 A | 183 | 100% |  |  |  | start no earlier than 2025-06-18 | SKAPHE |  |  | 100% | 0% |  |
| 185 | 1.6.7 | **Proceso de Intervención en Conservación Documental-Primeros Auxilios** |  | 74d | 2025-06-09 A | 2025-09-24 |  | 70% | 22.44d | 54d |  |  | SKAPHE | 2424h | 1653.18h | 61% | -9% |  |
| 186 | 1.6.7.1 | Actividades de primeros auxilios |  | 65d | 2025-06-09 A | 2025-09-11 | 183 | 74% | 16.9d | 63d | 12d | start no earlier than 2025-06-09 | SKAPHE | 520h | 384.8h | 69% | -5% |  |
| 187 | 1.6.7.2 | **Realizar entregas de libros** |  | 56d | 2025-07-07 A | 2025-09-24 |  | 67% | 18.44d | 54d |  |  | SKAPHE | 1312h | 882.65h | 48% | -19% |  |
| 188 | 1.6.7.2.1 | Entregas Primeros Auxilios |  | 54d | 2025-07-07 A | 2025-09-22 | 186SS+6d | 88% | 6.64d | 56d | 0d |  | SKAPHE | 432h | 378.88h | 50% | -38% |  |
| 189 | 1.6.7.2.2 | Aprobación entregas Primeros Auxilios |  | 54d | 2025-07-09 A | 2025-09-24 | 188SS+2d | 46% | 28.92d | 54d | 0d | finish no earlier than 2025-05-13 | SNR | 432h | 200.64h | 46% | 0% |  |
| 190 | 1.6.8 | **Proceso de Digitalizacion** |  | 63d | 2025-07-09 A | 2025-10-07 |  | 55% | 28.66d | 45d |  |  | SKAPHE | 1992h | 1122.4h | 40% | -15% |  |
| 191 | 1.6.8.1 | Realizar actividades de digitalización |  | 62d | 2025-07-10 A | 2025-10-07 | 189SS+2d | 55% | 27.9d | 45d | 0d |  | SKAPHE | 496h | 272.8h | 39% | -16% |  |
| 192 | 1.6.8.2 | **Realizar Entrega de libros** |  | 62d | 2025-07-09 A | 2025-10-06 |  | 54% | 28.52d | 46d |  |  | SKAPHE | 992h | 535.68h | 40% | -14% |  |
| 193 | 1.6.8.2.1 | Entregar libros digitalizados |  | 62d | 2025-07-09 A | 2025-10-06 | 191SS+10d | 54% | 28.52d | 46d |  |  | SKAPHE | 496h | 267.84h | 40% | -14% |  |
| 194 | 1.6.9 | **Proceso de Descripcion e Indexacion** |  | 62d | 2025-07-15 A | 2025-10-10 |  | 48% | 32.18d | 42d |  |  | SKAPHE | 1848h | 904.72h | 34% | -14% |  |
| 195 | 1.6.9.1 | Realizar actividades de descripción e indexación |  | 62d | 2025-07-15 A | 2025-10-10 | 191SS+3d | 54% | 28.52d | 42d | 19d |  | SKAPHE | 496h | 267.84h | 34% | -20% |  |
| 196 | 1.6.9.2 | **Realizar entrega de libros** |  | 37d | 2025-08-20 A | 2025-10-09 |  | 43% | 21.14d | 43d |  |  | SKAPHE | 856h | 398.35h | 0% | -43% |  |
| 197 | 1.6.9.2.1 | Entregar libros indexados |  | 35d | 2025-08-20 A | 2025-10-07 | 195SS+5d | 86% | 5d | 45d | 0d |  | SKAPHE | 280h | 240h | 0% | -86% |  |
| 198 | 1.6.9.2.2 | Aprobar libros digitalizados e indexados |  | 35d | 2025-08-22 | 2025-10-09 | 197SS+2d |  |  | 43d | 0d | finish no earlier than 2025-05-21 | SNR | 280h |  | 0% | 0% |  |
| 199 | 1.6.10 | **Proceso de Realmacenamiento en Unidades de Conservacion** |  | 43d | 2025-08-22 | 2025-10-22 |  |  |  | 17d |  |  | SKAPHE | 1264h |  | 0% | 0% |  |
| 200 | 1.6.10.1 | Realizar actividades de realmacenamiento |  | 35d | 2025-08-22 | 2025-10-09 | 198SS |  |  | 19d | 2d | start no earlier than 2025-08-20 | SKAPHE | 280h |  | 0% | 0% |  |

Notes:
- 188: 100 libros
- 193: 100 libros
- 197: 100 libros

| ID | WBS | Task | Type | Duration | Start | Finish | Predecessors | Complete | Remaining | Total slack | Free slack | Constraint | Resources | Work | Actual work | %Planeado | %Retraso | Text30 |
| --- | --- | --- | --- | --- | --- | --- | --- | --- | --- | --- | --- | --- | --- | --- | --- | --- | --- | --- |
| 201 | 1.6.10.2 | **Realizar entrega de libros** |  | 41d | 2025-08-26 | 2025-10-22 |  |  |  | 17d |  |  | SKAPHE | 640h |  | 0% | 0% |  |
| 202 | 1.6.10.2.1 | Entrega semanales realmacenamiento |  | 37d | 2025-08-26 | 2025-10-16 | 200SS |  |  | 17d | 0d | start no earlier than 2025-08-26 | SKAPHE | 296h |  | 0% | 0% |  |
| 203 | 1.6.10.2.2 | Aprobación semanales realmacenamiento |  | 39d | 2025-08-28 | 2025-10-22 | 202SS+2d |  |  | 17d | 16d |  | SNR | 16h |  | 0% | 0% |  |
| 204 | 1.6.11 | **Proceso Discos Duros** |  | 69d | 2025-08-26 | 2025-12-03 |  |  |  | 7d |  |  | SKAPHE | 2520h |  | 0% | 0% |  |
| 205 | 1.6.11.1 | Realizar copiado de DD | milestone | 60d | 2025-08-26 | 2025-11-20 | 198SS+2d |  |  | 7d | 0d |  | SKAPHE | 480h |  | 0% | 0% |  |
| 206 | 1.6.11.2 | **Realizar entrega de DD** |  | 64d | 2025-09-02 | 2025-12-03 |  |  |  | 7d |  |  | SKAPHE | 1488h |  | 0% | 0% |  |
| 207 | 1.6.11.2.1 | Entrega DD |  | 60d | 2025-09-02 | 2025-11-27 | 205SS+5d |  |  | 7d | 0d |  | SKAPHE | 480h |  | 0% | 0% |  |
| 208 | 1.6.11.2.2 | Realizar aprobación entrega DD | milestone | 62d | 2025-09-04 | 2025-12-03 | 207SS+2d |  |  | 7d |  | finish no earlier than 2025-05-28 | SNR | 496h |  | 0% | 0% |  |
| 209 | 1.6.12 | Traslado de Libros del Antiguo Sistema Registral al Archivo Central | milestone | 52d | 2025-09-26 | 2025-12-12 | 203SS+5d |  |  | 1d |  | start no earlier than 2025-09-26 | SKAPHE | 416h |  | 0% | 0% |  |
| 210 | 1.7 | **Sahagun** |  | 180d | 2025-03-20 A | 2025-12-12 |  | 19% | 145.58d | 1d |  |  |  | 6232h | 1099.53h | 54% | 35% | G1 |
| 211 | 1.7.1 | Visita tecnica de reconocimiento |  | 1d | 2025-03-20 A | 2025-03-20 A |  | 100% |  |  |  | start no earlier than 2025-03-20 | SKAPHE | 8h | 8h | 100% | 0% |  |
| 212 | 1.7.2 | Entrega informe Visita Tecnica | milestone | 0d | 2025-04-02 A | 2025-04-02 A |  | 100% |  |  |  | start no earlier than 2025-03-31 | SKAPHE |  |  | 100% | 0% |  |
| 213 | 1.7.3 | **Saneamiento Ambiental Preventivo** |  | 16d | 2025-06-20 A | 2025-07-15 A |  | 100% |  |  |  |  | SKAPHE | 256h | 256h | 100% | 0% |  |
| 214 | 1.7.3.1 | Actividades de saneamiento |  | 1d | 2025-06-20 A | 2025-06-20 A |  | 100% |  |  |  | start no earlier than 2025-06-20 | SKAPHE | 8h | 8h | 100% | 0% |  |
| 215 | 1.7.3.2 | Entrega de Informe Saneamiento Ambiental Preventivo |  | 15d | 2025-06-24 A | 2025-07-15 A | 214 | 100% |  |  |  | start no earlier than 2025-06-11 | SKAPHE | 120h | 120h | 100% | 0% |  |
| 216 | 1.7.4 | Alistamiento, Entrega y Embalaje |  | 9d | 2025-06-24 A | 2025-07-07 A | 214 | 100% |  |  |  | start no earlier than 2025-05-28 | SKAPHE | 72h | 72h | 100% | 0% |  |
| 217 | 1.7.5 | Cargue, Traslado y descargue |  | 1d | 2025-07-08 A | 2025-07-08 A | 216 | 100% |  |  |  | start no earlier than 2025-06-13 | SKAPHE | 8h | 8h | 100% | 0% |  |
| 218 | 1.7.6 | Entrega de acta de cargue y descargue | milestone | 0d | 2025-07-08 A | 2025-07-08 A | 217 | 100% |  |  |  |  | SKAPHE |  |  | 100% | 0% |  |
| 219 | 1.7.7 | **Proceso de Intervención en Conservación Documental-Primeros Auxilios** |  | 40d | 2025-07-09 A | 2025-09-04 |  | 65% | 14.07d | 68d |  |  | SKAPHE | 1208h | 755.52h | 63% | -3% |  |
| 220 | 1.7.7.1 | Actividades de primeros auxilios |  | 35d | 2025-07-09 A | 2025-08-28 | 217 | 87% | 4.55d | 73d |  |  | SKAPHE | 280h | 243.6h | 71% | -16% |  |
| 221 | 1.7.7.2 | **Realizar entregas de libros** |  | 27d | 2025-07-28 A | 2025-09-04 |  | 49% | 13.78d | 32d |  |  | SKAPHE | 608h | 312.41h | 44% | -5% |  |
| 222 | 1.7.7.2.1 | Entregas Primeros Auxilios |  | 24d | 2025-07-28 A | 2025-09-01 A | 220SS+6d | 100% |  |  |  |  | SKAPHE | 192h | 192h | 50% | -50% |  |
| 223 | 1.7.7.2.2 | Aprobación entregas Primeros Auxilios |  | 25d | 2025-07-30 | 2025-09-04 | 222SS+2d |  |  | 32d | 0d |  | SNR | 200h |  | 40% | 40% |  |
| 224 | 1.7.8 | **Proceso de Digitalizacion** |  | 44d | 2025-08-01 | 2025-10-03 |  |  |  | 32d |  |  | SKAPHE | 1168h |  | 18% | 18% |  |
| 225 | 1.7.8.1 | Realizar actividades de digitalización |  | 34d | 2025-08-01 | 2025-09-19 | 223SS+2d |  |  | 32d | 0d |  | SKAPHE | 272h |  | 24% | 24% |  |

Notes:
- 202: 100 libros
- 207: 100 libros
- 222: 168 libros

| ID | WBS | Task | Type | Duration | Start | Finish | Predecessors | Complete | Remaining | Total slack | Free slack | Constraint | Resources | Work | Actual work | %Planeado | %Retraso | Text30 |
| --- | --- | --- | --- | --- | --- | --- | --- | --- | --- | --- | --- | --- | --- | --- | --- | --- | --- | --- |
| 226 | 1.7.8.2 | **Realizar Entrega de libros** |  | 34d | 2025-08-19 | 2025-10-03 |  |  |  | 47d |  |  | SKAPHE | 544h |  | 0% | 0% |  |
| 227 | 1.7.8.2.1 | Entregar libros digitalizados |  | 34d | 2025-08-19 | 2025-10-03 | 225SS+10d |  |  | 47d |  |  | SKAPHE | 272h |  | 0% | 0% |  |
| 228 | 1.7.9 | **Proceso de Descripcion e Indexacion** |  | 52d | 2025-08-06 | 2025-10-21 |  |  |  | 16d |  |  | SKAPHE | 1376h |  | 10% | 10% |  |
| 229 | 1.7.9.1 | Realizar actividades de descripción e indexación |  | 36d | 2025-08-06 | 2025-09-26 | 225SS+3d |  |  | 32d | 17d |  | SKAPHE | 288h |  | 14% | 14% |  |
| 230 | 1.7.9.2 | **Realizar entrega de libros** |  | 30d | 2025-09-09 | 2025-10-21 |  |  |  | 15d |  |  | SKAPHE | 672h |  | 0% | 0% |  |
| 231 | 1.7.9.2.1 | Entregar libros indexados |  | 26d | 2025-09-09 | 2025-10-15 | 229SS+5d |  |  | 15d | 0d | start no earlier than 2025-09-09 | SKAPHE | 208h |  | 0% | 0% |  |
| 232 | 1.7.9.2.2 | Aprobar libros digitalizados e indexados |  | 28d | 2025-09-11 | 2025-10-21 | 231SS+2d |  |  | 15d | 0d |  | SNR | 224h |  | 0% | 0% |  |
| 233 | 1.7.10 | **Proceso de Realmacenamiento en Unidades de Conservacion** |  | 24d | 2025-09-18 | 2025-10-22 |  |  |  | 6d |  |  | SKAPHE | 384h |  | 0% | 0% |  |
| 234 | 1.7.10.1 | Realizar actividades de realmacenamiento |  | 15d | 2025-09-18 | 2025-10-08 | 232SS+5d |  |  | 15d | 14d |  | SKAPHE | 120h |  | 0% | 0% |  |
| 235 | 1.7.10.2 | **Realizar entrega de libros** |  | 5d | 2025-10-16 | 2025-10-22 |  |  |  | 1d |  |  | SKAPHE | 72h |  | 0% | 0% |  |
| 236 | 1.7.10.2.1 | Entrega semanales realmacenamiento |  | 1d | 2025-10-16 | 2025-10-16 | 234SS+5d |  |  | 1d | 0d | start no earlier than 2025-10-16 | SKAPHE | 8h |  | 0% | 0% |  |
| 237 | 1.7.10.2.2 | Aprobación semanales realmacenamiento |  | 3d | 2025-10-20 | 2025-10-22 | 236SS+2d |  |  | 1d | 0d |  | SNR | 24h |  | 0% | 0% |  |
| 238 | 1.7.11 | **Proceso Discos Duros** |  | 43d | 2025-09-15 | 2025-11-14 |  |  |  | 19d |  |  | SKAPHE | 1496h |  | 0% | 0% |  |
| 239 | 1.7.11.1 | Realizar copiado de DD |  | 35d | 2025-09-15 | 2025-11-04 | 232SS+2d |  |  | 19d | 0d |  | SKAPHE | 280h |  | 0% | 0% |  |
| 240 | 1.7.11.2 | **Realizar entrega de DD** |  | 38d | 2025-09-22 | 2025-11-14 |  |  |  | 19d |  |  | SKAPHE | 872h |  | 0% | 0% |  |
| 241 | 1.7.11.2.1 | Entrega DD |  | 35d | 2025-09-22 | 2025-11-11 | 239SS+5d |  |  | 19d | 0d |  | SKAPHE | 280h |  | 0% | 0% |  |
| 242 | 1.7.11.2.2 | Realizar aprobación entrega DD |  | 36d | 2025-09-24 | 2025-11-14 | 241SS+2d |  |  | 19d |  |  | SNR | 288h |  | 0% | 0% |  |
| 243 | 1.7.12 | Traslado de Libros del Antiguo Sistema Registral al Archivo Central |  | 32d | 2025-10-27 | 2025-12-12 | 237SS+5d |  |  | 1d |  | start no earlier than 2025-09-26 | SKAPHE | 256h |  | 0% | 0% |  |
| 244 | 1.8 | **Magangue** |  | 179d | 2025-03-21 A | 2025-12-12 |  | 7% | 166.56d | 1d |  |  |  | 5080h | 312h | 54% | 47% | G2 |
| 245 | 1.8.1 | Visita tecnica de reconocimiento |  | 1d | 2025-03-21 A | 2025-03-21 A |  | 100% |  |  |  | start no earlier than 2025-03-21 | SKAPHE | 8h | 8h | 100% | 0% |  |
| 246 | 1.8.2 | Entrega informe Visita Tecnica | milestone | 0d | 2025-04-02 A | 2025-04-02 A |  | 100% |  |  |  | start no earlier than 2025-03-31 | SKAPHE |  |  | 100% | 0% |  |
| 247 | 1.8.3 | **Saneamiento Ambiental Preventivo** |  | 16d | 2025-07-08 A | 2025-07-29 A |  | 100% |  |  |  |  | SKAPHE | 256h | 256h | 100% | 0% |  |
| 248 | 1.8.3.1 | Realizar actividades de saneamiento ambiental |  | 1d | 2025-07-08 A | 2025-07-08 A |  | 100% |  |  |  | start no earlier than 2025-07-08 | SKAPHE | 8h | 8h | 100% | 0% |  |
| 249 | 1.8.3.2 | Entrega de Informe Saneamiento Ambiental Preventivo |  | 15d | 2025-07-09 A | 2025-07-29 A | 248 | 100% |  |  |  | start no earlier than 2025-07-09 | SKAPHE | 120h | 120h | 100% | 0% |  |
| 250 | 1.8.4 | Alistamiento, Entrega y Embalaje |  | 5d | 2025-07-09 A | 2025-07-15 A | 248 | 100% |  |  |  | start no earlier than 2025-06-04 | SKAPHE | 40h | 40h | 100% | 0% |  |
| 251 | 1.8.5 | Cargue, Traslado y descargue |  | 1d | 2025-07-16 A | 2025-07-16 A | 250 | 100% |  |  |  | start no earlier than 2025-06-16 | SKAPHE | 8h | 8h | 100% | 0% |  |
| 252 | 1.8.6 | Entrega de acta de cargue y descargue | milestone | 0d | 2025-07-16 A | 2025-07-16 A | 251 | 100% |  |  |  | start no earlier than 2025-07-15 | SKAPHE |  |  | 100% | 0% |  |

Notes:
- 227: 168 libros
- 231: 168 libros
- 236: 168 libros
- 241: 168 libros

| ID | WBS | Task | Duration | Start | Finish | Predecessors | Total slack | Free slack | Constraint | Resources | Work | %Planeado | %Retraso |
| --- | --- | --- | --- | --- | --- | --- | --- | --- | --- | --- | --- | --- | --- |
| 253 | 1.8.7 | **Proceso de Intervención en Conservación Documental-Primeros Auxilios** | 47d | 2025-07-17 | 2025-09-23 |  | 30d |  |  | SKAPHE | 960h | 40% | 40% |
| 254 | 1.8.7.1 | Actividades de conservación primeros auxilios | 30d | 2025-07-17 | 2025-08-29 | 251 | 47d | 24d |  | SKAPHE | 240h | 63% | 63% |
| 255 | 1.8.7.2 | **Realizar entrega de libros** | 17d | 2025-09-01 | 2025-09-23 |  | 23d |  |  | SKAPHE | 344h | 0% | 0% |
| 256 | 1.8.7.2.1 | Entregas Primeros Auxilios | 11d | 2025-09-01 | 2025-09-15 | 254SS+6d | 23d | 0d | start no earlier than 2025-09-01 | SKAPHE | 88h | 0% | 0% |
| 257 | 1.8.7.2.2 | Aprobación entregas Primeros Auxilios | 15d | 2025-09-03 | 2025-09-23 | 256SS+2d | 23d | 0d |  | SNR | 120h | 0% | 0% |
| 258 | 1.8.8 | **Proceso de Digitalizacion** | 40d | 2025-09-05 | 2025-10-31 |  | 23d |  |  | SKAPHE | 1040h | 0% | 0% |
| 259 | 1.8.8.1 | Realizar actividades de digitalización | 30d | 2025-09-05 | 2025-10-17 | 257SS+2d | 23d | 0d |  | SKAPHE | 240h | 0% | 0% |
| 260 | 1.8.8.2 | **Realizar entrega de libros** | 30d | 2025-09-19 | 2025-10-31 |  | 28d |  |  | SKAPHE | 480h | 0% | 0% |
| 261 | 1.8.8.2.1 | Entregar libros digitalizados | 30d | 2025-09-19 | 2025-10-31 | 259SS+10d | 28d |  |  | SKAPHE | 240h | 0% | 0% |
| 262 | 1.8.9 | **Proceso de Descripcion e Indexacion** | 36d | 2025-09-10 | 2025-10-30 |  | 18d |  |  | SKAPHE | 752h | 0% | 0% |
| 263 | 1.8.9.1 | Actividades de descripción e indexación | 31d | 2025-09-10 | 2025-10-23 | 259SS+3d | 23d | 19d |  | SKAPHE | 248h | 0% | 0% |
| 264 | 1.8.9.2 | **Realizar entrega de libros** | 12d | 2025-10-15 | 2025-10-30 |  | 4d |  |  | SKAPHE | 216h | 0% | 0% |
| 265 | 1.8.9.2.1 | Entregar libros indexados | 5d | 2025-10-15 | 2025-10-21 | 263SS+5d | 4d | 0d | start no earlier than 2025-10-15 | SKAPHE | 40h | 0% | 0% |
| 266 | 1.8.9.2.2 | Aprobar libros digitalizados e indexados | 10d | 2025-10-17 | 2025-10-30 | 265SS+2d | 4d | 0d |  | SNR | 80h | 0% | 0% |
| 267 | 1.8.10 | **Proceso de Realmacenamiento en Unidades de Conservacion** | 30d | 2025-10-24 | 2025-12-09 |  | 4d |  |  | SKAPHE | 816h | 0% | 0% |
| 268 | 1.8.10.1 | Actividades de realmacenamiento | 30d | 2025-10-24 | 2025-12-09 | 266SS+5d | 4d |  |  | SKAPHE | 240h | 0% | 0% |
| 269 | 1.8.10.2 | **Realizar entrega de libros** | 17d | 2025-11-10 | 2025-12-03 |  | 1d |  |  | SKAPHE | 336h | 0% | 0% |
| 270 | 1.8.10.2.1 | Entrega semanales realmacenamiento | 10d | 2025-11-10 | 2025-11-24 | 268SS+5d | 1d | 0d | start no earlier than 2025-11-10 | SKAPHE | 80h | 0% | 0% |
| 271 | 1.8.10.2.2 | Aprobación semanales realmacenamiento | 15d | 2025-11-12 | 2025-12-03 | 270SS+2d | 1d | 0d |  | SNR | 120h | 0% | 0% |
| 272 | 1.8.11 | **Proceso de discos Duros** | 32d | 2025-10-21 | 2025-12-05 |  | 5d |  |  | SKAPHE | 1072h | 0% | 0% |
| 273 | 1.8.11.1 | Realizar copiado de DD | 25d | 2025-10-21 | 2025-11-26 | 266SS+2d | 5d | 0d |  | SKAPHE | 200h | 0% | 0% |
| 274 | 1.8.11.2 | **Entrega de discos duros** | 27d | 2025-10-28 | 2025-12-05 |  | 5d |  |  | SKAPHE | 616h | 0% | 0% |
| 275 | 1.8.11.2.1 | Entrega DD | 25d | 2025-10-28 | 2025-12-03 | 273SS+5d | 5d | 0d |  | SKAPHE | 200h | 0% | 0% |
| 276 | 1.8.11.2.2 | Realizar aprobación entrega DD | 25d | 2025-10-30 | 2025-12-05 | 275SS+2d | 5d |  |  | SNR | 200h | 0% | 0% |
| 277 | 1.8.12 | Traslado de Libros del Antiguo Sistema Registral al Archivo Central | 16d | 2025-11-20 | 2025-12-12 | 271SS+5d | 1d |  |  | SKAPHE | 128h | 0% | 0% |

Notes:
- 256: 82 libros
- 261: 82 libros
- 265: 82 libros
- 270: 82 libros
- 275: 82 libros

| ID | WBS | Task | Type | Duration | Start | Finish | Predecessors | Complete | Remaining | Total slack | Free slack | Constraint | Resources | Work | Actual work | %Planeado | %Retraso | Text30 |
| --- | --- | --- | --- | --- | --- | --- | --- | --- | --- | --- | --- | --- | --- | --- | --- | --- | --- | --- |
| 278 | 1.9 | **Mompox** |  | 179d | 2025-03-21 A | 2025-12-12 |  | 4% | 172.25d | 1d |  |  |  | 4384h | 80h | 54% | 50% | G2 |
| 279 | 1.9.1 | Visita tecnica de reconocimiento |  | 1d | 2025-03-21 A | 2025-03-21 A |  | 100% |  |  |  | start no earlier than 2025-03-21 | SKAPHE | 8h | 8h | 100% | 0% |  |
| 280 | 1.9.2 | Entrega informe Visita Tecnica | milestone | 0d | 2025-04-02 A | 2025-04-02 A |  | 100% |  |  |  | start no earlier than 2025-03-31 | SKAPHE |  |  | 100% | 0% |  |
| 281 | 1.9.3 | **Saneamiento Ambiental Preventivo** |  | 16d | 2025-07-17 A | 2025-08-08 |  | 6% | 15d | 86d |  |  | SKAPHE | 256h | 16h | 100% | 94% |  |
| 282 | 1.9.3.1 | Realizar actividades de saneamiento ambiental |  | 1d | 2025-07-17 A | 2025-07-17 A |  | 100% |  |  |  | start no earlier than 2025-07-17 | SKAPHE | 8h | 8h | 100% | 0% |  |
| 283 | 1.9.3.2 | Entrega de Informe Saneamiento Ambiental Preventivo |  | 15d | 2025-07-18 | 2025-08-08 | 282 |  |  | 86d |  | start no earlier than 2025-07-18 | SKAPHE | 120h |  | 100% | 100% |  |
| 284 | 1.9.4 | Alistamiento, Entrega y Embalaje |  | 6d | 2025-07-18 A | 2025-07-25 A | 282 | 100% |  |  |  | start no earlier than 2025-06-24 | SKAPHE | 48h | 48h | 100% | 0% |  |
| 285 | 1.9.5 | Cargue, Traslado y descargue |  | 1d | 2025-07-28 A | 2025-07-28 A | 284 | 100% |  |  |  | start no earlier than 2025-07-01 | SKAPHE | 8h | 8h | 100% | 0% |  |
| 286 | 1.9.6 | Entrega de acta de cargue y descargue |  | 1d | 2025-07-29 A | 2025-07-29 A | 285 | 100% |  |  |  |  |  |  |  | 100% | 0% |  |
| 287 | 1.9.7 | **Proceso de Intervención en Conservación Documental-Primeros Auxilios** |  | 57d | 2025-07-31 | 2025-10-22 |  |  |  | 12d |  |  | SKAPHE | 968h |  | 16% | 16% |  |
| 288 | 1.9.7.1 | Actividades de primeros auxilios |  | 26d | 2025-07-31 | 2025-09-08 | 285 |  |  | 43d | 34d | start no earlier than 2025-07-31 | SKAPHE | 208h |  | 35% | 35% |  |
| 289 | 1.9.7.2 | **Realizar entrega de libros** |  | 17d | 2025-09-29 | 2025-10-22 |  |  |  | 9d |  |  | SKAPHE | 304h |  | 0% | 0% |  |
| 290 | 1.9.7.2.1 | Entregas Primeros Auxilios |  | 6d | 2025-09-29 | 2025-10-06 | 288SS+6d |  |  | 9d | 0d | start no earlier than 2025-09-29 | SKAPHE | 48h |  | 0% | 0% |  |
| 291 | 1.9.7.2.2 | Aprobación entregas Primeros Auxilios |  | 15d | 2025-10-01 | 2025-10-22 | 290SS+2d |  |  | 9d | 0d |  | SNR | 120h |  | 0% | 0% |  |
| 292 | 1.9.8 | **Proceso de Digitalizacion** |  | 36d | 2025-10-03 | 2025-11-26 |  |  |  | 9d |  |  | SKAPHE | 912h |  | 0% | 0% |  |
| 293 | 1.9.8.1 | Realizar actividades de digitalización |  | 26d | 2025-10-03 | 2025-11-11 | 291SS+2d |  |  | 9d | 0d |  | SKAPHE | 208h |  | 0% | 0% |  |
| 294 | 1.9.8.2 | **Realizar entrega de libros** |  | 26d | 2025-10-20 | 2025-11-26 |  |  |  | 12d |  |  | SKAPHE | 416h |  | 0% | 0% |  |
| 295 | 1.9.8.2.1 | Entregar libros digitalizados |  | 26d | 2025-10-20 | 2025-11-26 | 293SS+10d |  |  | 12d |  |  | SKAPHE | 208h |  | 0% | 0% |  |
| 296 | 1.9.9 | **Proceso de Descripcion e Indexacion** |  | 35d | 2025-10-08 | 2025-11-28 |  |  |  | 1d |  |  | SKAPHE | 912h |  | 0% | 0% |  |
| 297 | 1.9.9.1 | Realizar actividades de descripción e indexación |  | 26d | 2025-10-08 | 2025-11-14 | 293SS+3d |  |  | 9d | 8d |  | SKAPHE | 208h |  | 0% | 0% |  |
| 298 | 1.9.9.2 | **Realizar entrega de libros** |  | 22d | 2025-10-28 | 2025-11-28 |  |  |  | 1d |  |  | SKAPHE | 424h |  | 0% | 0% |  |
| 299 | 1.9.9.2.1 | Entregar libros indexados |  | 11d | 2025-10-28 | 2025-11-12 | 297SS+5d |  |  | 1d | 0d | start no earlier than 2025-10-28 | SKAPHE | 88h |  | 0% | 0% |  |
| 300 | 1.9.9.2.2 | Aprobar libros digitalizados e indexados |  | 20d | 2025-10-30 | 2025-11-28 | 299SS+2d |  |  | 1d | 0d |  | SNR | 160h |  | 0% | 0% |  |
| 301 | 1.9.10 | **Proceso de Realmacenamiento en Unidades de Conservacion** |  | 22d | 2025-11-07 | 2025-12-10 |  |  |  | 3d |  |  | SKAPHE | 392h |  | 0% | 0% |  |
| 302 | 1.9.10.1 | Realizar actividades de realmacenamiento |  | 20d | 2025-11-07 | 2025-12-05 | 300SS+5d |  |  | 5d |  |  | SKAPHE | 160h |  | 0% | 0% |  |

Notes:
- 290: 117 libros
- 295: 117 libros
- 299: 117 libros

| ID | WBS | Task | Type | Duration | Start | Finish | Predecessors | Complete | Remaining | Total slack | Free slack | Constraint | Resources | Work | Actual work | %Planeado | %Retraso |
| --- | --- | --- | --- | --- | --- | --- | --- | --- | --- | --- | --- | --- | --- | --- | --- | --- | --- |
| 303 | 1.9.10.2 | **Realizar entrega de libros** |  | 4d | 2025-12-04 | 2025-12-10 |  |  |  | 3d |  |  | SKAPHE | 56h |  | 0% | 0% |
| 304 | 1.9.10.2.1 | Entrega semanales realmacenamiento |  | 1d | 2025-12-04 | 2025-12-04 | 302SS+5d |  |  | 3d | 0d | start no earlier than 2025-12-04 | SKAPHE | 8h |  | 0% | 0% |
| 305 | 1.9.10.2.2 | Aprobación semanales realmacenamiento |  | 2d | 2025-12-09 | 2025-12-10 | 304SS+2d |  |  | 3d |  |  | SNR | 16h |  | 0% | 0% |
| 306 | 1.9.11 | **Proceso de discos Duros** |  | 27d | 2025-11-04 | 2025-12-12 |  |  |  | 1d |  |  | SKAPHE | 872h |  | 0% | 0% |
| 307 | 1.9.11.1 | Realizar copiado de DD |  | 20d | 2025-11-04 | 2025-12-02 | 300SS+2d |  |  | 1d | 0d |  | SKAPHE | 160h |  | 0% | 0% |
| 308 | 1.9.11.2 | **Entrega de DD** |  | 22d | 2025-11-11 | 2025-12-12 |  |  |  | 1d |  |  | SKAPHE | 496h |  | 0% | 0% |
| 309 | 1.9.11.2.1 | Entrega DD |  | 20d | 2025-11-11 | 2025-12-10 | 307SS+5d |  |  | 1d | 0d |  | SKAPHE | 160h |  | 0% | 0% |
| 310 | 1.9.11.2.2 | Realizar aprobación entrega DD |  | 20d | 2025-11-13 | 2025-12-12 | 309SS+2d |  |  | 1d |  |  | SNR | 160h |  | 0% | 0% |
| 311 | 1.9.12 | Traslado de Libros del Antiguo Sistema Registral al Archivo Central |  | 1d | 2025-12-12 | 2025-12-12 | 305SS |  |  | 1d |  | start no earlier than 2025-12-12 | SKAPHE | 8h |  | 0% | 0% |
| 312 | 1.10 | Intervencion tecnica por Demanda /Prestamo de Unidades documentales en porceos de Digitalizacion |  | 172d | 2025-03-17 A | 2025-12-15 |  | 59% | 70.52d | 0.4d |  |  | SKAPHE | 1376h | 811.84h | 59% | 0% |
| 313 | 1.11 | Control Calidad Tranversal procesos | milestone | 184d | 2025-03-17 A | 2025-12-15 |  | 55% | 82.8d | 0d |  | start no earlier than 2025-03-17 | SKAPHE | 1472h | 809.6h | 55% | 0% |
| 314 | 1.12 | **Monitoreo y Control** |  | 170d | 2025-04-03 A | 2025-12-15 |  |  | 170d | 1d |  |  |  |  |  | 52% | 52% |
| 315 | 1.12.1 | **Reuniones de seguimiento quincenal** |  | 143d | 2025-05-05 A | 2025-12-02 |  |  | 143d | 9d |  |  |  |  |  | 48% | 48% |
| 316 | 1.12.1.1 | Reunión de seguimiento nro 1 | milestone | 0d | 2025-05-05 A | 2025-05-05 A |  | 100% |  |  |  | start no earlier than 2025-05-05 | SKAPHE; SNR |  |  | 100% | 0% |
| 317 | 1.12.1.2 | Reunión de seguimiento nro 2 | milestone | 0d | 2025-05-20 A | 2025-05-20 A |  | 100% |  |  |  | start no earlier than 2025-05-20 | SKAPHE; SNR |  |  | 100% | 0% |
| 318 | 1.12.1.3 | Reunión de seguimiento nro 3 | milestone | 0d | 2025-06-03 A | 2025-06-03 A |  | 100% |  |  |  | start no earlier than 2025-06-03 | SKAPHE; SNR |  |  | 100% | 0% |
| 319 | 1.12.1.4 | Reunión de seguimiento nro 4 | milestone | 0d | 2025-06-17 A | 2025-06-17 A |  | 100% |  |  |  | start no earlier than 2025-06-17 | SKAPHE; SNR |  |  | 100% | 0% |
| 320 | 1.12.1.5 | Reunión de seguimiento nro 5 | milestone | 0d | 2025-07-01 A | 2025-07-01 A |  | 100% |  |  |  | start no earlier than 2025-07-01 | SKAPHE; SNR |  |  | 100% | 0% |
| 321 | 1.12.1.6 | Reunión de seguimiento nro 6 | milestone | 0d | 2025-07-15 A | 2025-07-15 A |  | 100% |  |  |  | start no earlier than 2025-07-15 | SKAPHE; SNR |  |  | 100% | 0% |
| 322 | 1.12.1.7 | Reunión de seguimiento nro 7 | milestone | 0d | 2025-07-29 A | 2025-07-29 A |  | 100% |  |  |  | start no earlier than 2025-07-29 | SKAPHE; SNR |  |  | 100% | 0% |
| 323 | 1.12.1.8 | Reunión de seguimiento nro 8 | milestone | 0d | 2025-08-12 A | 2025-08-12 A |  | 100% |  |  |  | start no earlier than 2025-08-12 | SKAPHE; SNR |  |  | 100% | 0% |
| 324 | 1.12.1.9 | Reunión de seguimiento nro 9 | milestone | 0d | 2025-08-26 | 2025-08-26 |  |  |  | 76d |  | start no earlier than 2025-08-26 | SKAPHE; SNR |  |  | 0% | 0% |
| 325 | 1.12.1.10 | Reunión de seguimiento nro 10 | milestone | 0d | 2025-09-09 | 2025-09-09 |  |  |  | 66d |  | start no earlier than 2025-09-09 | SKAPHE; SNR |  |  | 0% | 0% |
| 326 | 1.12.1.11 | Reunión de seguimiento nro 11 | milestone | 0d | 2025-09-23 | 2025-09-23 |  |  |  | 56d |  | start no earlier than 2025-09-23 | SKAPHE; SNR |  |  | 0% | 0% |
| 327 | 1.12.1.12 | Reunión de seguimiento nro 12 | milestone | 0d | 2025-10-07 | 2025-10-07 |  |  |  | 46d |  | start no earlier than 2025-10-07 | SKAPHE; SNR |  |  | 0% | 0% |
| 328 | 1.12.1.13 | Reunión de seguimiento nro 13 | milestone | 0d | 2025-10-21 | 2025-10-21 |  |  |  | 37d |  | start no earlier than 2025-10-21 | SKAPHE; SNR |  |  | 0% | 0% |
| 329 | 1.12.1.14 | Reunión de seguimiento nro 14 | milestone | 0d | 2025-11-04 | 2025-11-04 |  |  |  | 28d |  | start no earlier than 2025-11-04 | SKAPHE; SNR |  |  | 0% | 0% |
| 330 | 1.12.1.15 | Reunión de seguimiento nro 15 | milestone | 0d | 2025-11-18 | 2025-11-18 |  |  |  | 19d |  | start no earlier than 2025-11-18 | SKAPHE; SNR |  |  | 0% | 0% |
| 331 | 1.12.1.16 | Reunión de seguimiento nro 16 | milestone | 0d | 2025-12-02 | 2025-12-02 |  |  |  | 9d |  | start no earlier than 2025-12-02 | SKAPHE; SNR |  |  | 0% | 0% |

Notes:
- 304: 117 libros
- 309: 82 libros
- 313: Entrega Informe

| ID | WBS | Task | Type | Duration | Start | Finish | Complete | Remaining | Total slack | Constraint | Resources | %Planeado | %Retraso |
| --- | --- | --- | --- | --- | --- | --- | --- | --- | --- | --- | --- | --- | --- |
| 332 | 1.12.2 | **Informes Mensuales** |  | 170d | 2025-04-03 A | 2025-12-15 |  | 170d | 1d |  |  | 52% | 52% |
| 333 | 1.12.2.1 | Informe marzo-2025 | milestone | 0d | 2025-04-03 A | 2025-04-03 A | 100% |  |  | start no earlier than 2025-04-03 | SKAPHE | 100% | 0% |
| 334 | 1.12.2.2 | Informe abril-2025 | milestone | 0d | 2025-05-05 A | 2025-05-05 A | 100% |  |  | start no earlier than 2025-05-05 | SKAPHE | 100% | 0% |
| 335 | 1.12.2.3 | Informe mayo-2025 | milestone | 0d | 2025-06-03 A | 2025-06-03 A | 100% |  |  | start no earlier than 2025-06-03 | SKAPHE | 100% | 0% |
| 336 | 1.12.2.4 | Informe junio-2025 | milestone | 0d | 2025-07-03 A | 2025-07-03 A | 100% |  |  | start no earlier than 2025-07-03 | SKAPHE | 100% | 0% |
| 337 | 1.12.2.5 | Informe julio-2025 | milestone | 0d | 2025-08-04 A | 2025-08-04 A | 100% |  |  | start no earlier than 2025-08-04 | SKAPHE | 100% | 0% |
| 338 | 1.12.2.6 | Informe agosto-2025 | milestone | 0d | 2025-09-03 | 2025-09-03 |  |  | 70d | start no earlier than 2025-09-03 | SKAPHE | 0% | 0% |
| 339 | 1.12.2.7 | Informe septiembre-2025 | milestone | 0d | 2025-10-03 | 2025-10-03 |  |  | 48d | start no earlier than 2025-10-03 | SKAPHE | 0% | 0% |
| 340 | 1.12.2.8 | Informe octubre-2025 | milestone | 0d | 2025-11-04 | 2025-11-04 |  |  | 28d | start no earlier than 2025-11-04 | SKAPHE | 0% | 0% |
| 341 | 1.12.2.9 | Informe noviembre-2025 | milestone | 0d | 2025-12-04 | 2025-12-04 |  |  | 7d | start no earlier than 2025-12-04 | SKAPHE | 0% | 0% |
| 342 | 1.12.2.10 | Informe diciembre-2025 | milestone | 0d | 2025-12-15 | 2025-12-15 |  |  | 1d | start no earlier than 2025-12-15 | SKAPHE | 0% | 0% |
| 343 | 1.12.3 | Informe de Cierre | milestone | 0d | 2025-12-15 | 2025-12-15 |  |  | 1d | start no earlier than 2025-12-15 | SKAPHE | 0% | 0% |
